# 2007_projects_Jan

Schedule from MS Project, 2007-01-02 to 2008-01-14.
MBARI

## Calendars

- Standard: Mon-Fri 08:00-12:00, 13:00-17:00; Sat-Sun off.

## Resources

| Resource |
| --- |
| EE |
| SE |
| ME |
| EE Tech |
| ME Tech |
| Machinist |
| Supp Eng |
| SE Tech |
| EE (Scott) |
| ME (Andy) |

## Schedule

| ID | WBS | Task | Duration | Start | Finish | Predecessors | Total slack | Free slack | Resources | Work |
| --- | --- | --- | --- | --- | --- | --- | --- | --- | --- | --- |
| 1 | 1 | **200001 Ocean Chemistry Greenhouse Gases** | 225d | 2007-01-02 | 2007-11-12 |  | 45d |  |  | 1416h |
| 2 | 1.1 | **CDR single axis PUP** | 25d | 2007-01-02 | 2007-02-05 |  | 45d | 0d |  | 80h |
| 3 | 1.1.1 | EE | 25d | 2007-01-02 | 2007-02-05 |  | 225d |  | EE [20%] | 40h |
| 4 | 1.1.2 | ME | 25d | 2007-01-02 | 2007-02-05 |  | 225d |  | ME [20%] | 40h |
| 5 | 1.2 | **Build test PUP** | 90d | 2007-02-06 | 2007-06-11 | 2 | 155d |  |  | 584h |
| 6 | 1.2.1 | EE | 90d | 2007-02-06 | 2007-06-11 |  | 155d |  | EE [11.1%] | 80h |
| 7 | 1.2.2 | ME | 90d | 2007-02-06 | 2007-06-11 |  | 155d |  | ME [16.7%] | 120h |
| 8 | 1.2.3 | SE | 90d | 2007-02-06 | 2007-06-11 |  | 155d |  | SE [11.1%] | 80h |
| 9 | 1.2.4 | EE Tech | 90d | 2007-02-06 | 2007-06-11 |  | 155d |  | EE Tech [14.4%] | 104h |
| 10 | 1.2.5 | ME Tech | 90d | 2007-02-06 | 2007-06-11 |  | 155d |  | ME Tech [22.2%] | 160h |
| 11 | 1.2.6 | Machinist | 90d | 2007-02-06 | 2007-06-11 |  | 155d |  | Machinist [5.6%] | 40h |
| 12 | 1.3 | **Concept mini probe head** | 20d | 2007-02-06 | 2007-03-05 | 2 | 45d | 0d |  | 112h |
| 13 | 1.3.1 | EE | 20d | 2007-02-06 | 2007-03-05 |  | 45d |  | EE [25%] | 40h |
| 14 | 1.3.2 | ME | 20d | 2007-02-06 | 2007-03-05 |  | 45d |  | ME [10%] | 16h |
| 15 | 1.3.3 | SE | 20d | 2007-02-06 | 2007-03-05 |  | 45d |  | SE [25%] | 40h |
| 16 | 1.3.4 | ME Tech | 20d | 2007-02-06 | 2007-03-05 |  | 45d |  | ME Tech [10%] | 16h |
| 17 | 1.4 | **Probe head PDR/CDR** | 130d | 2007-03-06 | 2007-09-03 | 12 | 45d | 0d |  | 224h |
| 18 | 1.4.1 | EE | 130d | 2007-03-06 | 2007-09-03 |  | 45d |  | EE [2.3%] | 24h |
| 19 | 1.4.2 | ME | 130d | 2007-03-06 | 2007-09-03 |  | 45d |  | ME [15.4%] | 160h |
| 20 | 1.4.3 | SE | 130d | 2007-03-06 | 2007-09-03 |  | 45d |  | SE [2.3%] | 24h |
| 21 | 1.4.4 | ME Tech | 130d | 2007-03-06 | 2007-09-03 |  | 45d |  | ME Tech [1.5%] | 16h |
| 22 | 1.5 | **Build probe head** | 50d | 2007-09-04 | 2007-11-12 | 17 | 45d |  |  | 416h |
| 23 | 1.5.1 | ME | 50d | 2007-09-04 | 2007-11-12 |  | 45d |  | ME [20%] | 80h |
| 24 | 1.5.2 | SE | 50d | 2007-09-04 | 2007-11-12 |  | 45d |  | SE [6%] | 24h |
| 25 | 1.5.3 | EE Tech | 50d | 2007-09-04 | 2007-11-12 |  | 45d |  | EE Tech [26%] | 104h |
| 26 | 1.5.4 | ME Tech | 50d | 2007-09-04 | 2007-11-12 |  | 45d |  | ME Tech [42%] | 168h |
| 27 | 1.5.5 | Machinist | 50d | 2007-09-04 | 2007-11-12 |  | 45d |  | Machinist [10%] | 40h |

| ID | WBS | Task | Type | Duration | Start | Finish | Predecessors | Total slack | Free slack | Constraint | Resources | Work |
| --- | --- | --- | --- | --- | --- | --- | --- | --- | --- | --- | --- | --- |
| 28 | 2 | **200009 Proto Multi-Sensor Ocean Floor Observ for MARS** |  | 201d? | 2007-01-02 | 2007-10-10 |  | 69d |  |  |  | 880h |
| 29 | 2.1 | EE |  | 200d | 2007-01-02 | 2007-10-08 |  | 70d |  |  | EE [30%] | 480h |
| 30 | 2.2 | EE Tech |  | 200d | 2007-01-02 | 2007-10-08 |  | 70d |  |  | EE Tech [12.5%] | 200h |
| 31 | 2.3 | ME Tech |  | 200d | 2007-01-02 | 2007-10-08 |  | 70d |  |  | EE Tech [12.5%] | 200h |
| 32 | 2.4 | Requirements, design to PDR |  | 1d? | 2007-01-02 | 2007-01-02 |  | 269d |  |  |  |  |
| 33 | 2.5 | PDR | milestone | 0d | 2007-03-01 | 2007-03-01 |  | 228d |  | start no earlier than 2007-03-01 |  |  |
| 34 | 2.6 | Mechanical, electrical system design to CDR |  | 1d? | 2007-01-02 | 2007-01-02 |  | 269d |  |  |  |  |
| 35 | 2.7 | Software development to CDR |  | 1d? | 2007-01-02 | 2007-01-02 |  | 269d |  |  |  |  |
| 36 | 2.8 | CDR | milestone | 0d | 2007-05-31 | 2007-05-31 |  | 163d |  | start no earlier than 2007-05-31 |  |  |
| 37 | 2.9 | Fabricate electronics module |  | 1d? | 2007-01-02 | 2007-01-02 |  | 269d |  |  |  |  |
| 38 | 2.10 | Build SIIMs, extension cables |  | 1d? | 2007-01-02 | 2007-01-02 |  | 269d |  |  |  |  |
| 39 | 2.11 | System Integration |  | 1d? | 2007-01-02 | 2007-01-02 |  | 269d |  |  |  |  |
| 40 | 2.12 | Bench test |  | 1d? | 2007-01-02 | 2007-01-02 |  | 269d |  |  |  |  |
| 41 | 2.13 | Cold test |  | 1d? | 2007-01-02 | 2007-01-02 |  | 269d |  |  |  |  |
| 42 | 2.14 | Test tank test |  | 1d? | 2007-01-02 | 2007-01-02 |  | 269d |  |  |  |  |
| 43 | 2.15 | Deploy system | milestone | 0d | 2007-10-10 | 2007-10-10 |  | 69d |  | start no earlier than 2007-10-10 |  |  |
| 44 | 3 | **200010 Continental Margins** |  | 81d | 2007-03-05 | 2007-06-26 |  | 145d |  |  |  | 160h |
| 45 | 3.1 | ME (Vibracore mods) |  | 30d | 2007-03-05 | 2007-04-13 |  | 166d | 0d | start no earlier than 2007-03-05 | ME [33.3%] | 80h |
| 46 | 3.2 | Machinist (vibracore mods) |  | 30d | 2007-04-16 | 2007-05-25 | 45 | 166d |  |  | Machinist [33.3%] | 80h |
| 47 | 3.3 | Ship time to test vibracore mods | milestone | 0d | 2007-06-26 | 2007-06-26 |  | 145d |  | start no earlier than 2007-06-26 |  |  |
| 48 | 4 | **200103 MDUC: Core CTD** |  | 250d | 2007-01-02 | 2007-12-17 |  | 20d |  |  |  | 440h |
| 49 | 4.1 | Supp Eng |  | 250d | 2007-01-02 | 2007-12-17 |  | 20d |  |  | Supp Eng [22%] | 440h |
| 50 | 5 | **200105 MDUC: Core Nav** |  | 250d | 2007-01-02 | 2007-12-17 |  | 20d |  |  |  | 80h |
| 51 | 5.1 | Supp Eng |  | 250d | 2007-01-02 | 2007-12-17 |  | 20d |  |  | Supp Eng [4%] | 80h |

| ID | WBS | Task | Duration | Start | Finish | Predecessors | Total slack | Free slack | Constraint | Resources | Work |
| --- | --- | --- | --- | --- | --- | --- | --- | --- | --- | --- | --- |
| 52 | 6 | **200108 Midwater Ecology** | 250d | 2007-01-02 | 2007-12-17 |  | 20d |  |  |  | 80h |
| 53 | 6.1 | ME Tech | 250d | 2007-01-02 | 2007-12-17 |  | 20d |  |  | ME Tech [2.4%] | 48h |
| 54 | 6.2 | Supp Eng | 250d | 2007-01-02 | 2007-12-17 |  | 20d |  |  | Supp Eng [1.6%] | 32h |
| 55 | 7 | **200109 MDUC: Core Mooring Data** | 250d | 2007-01-02 | 2007-12-17 |  | 20d |  |  |  | 400h |
| 56 | 7.1 | Supp Eng | 250d | 2007-01-02 | 2007-12-17 |  | 20d |  |  | Supp Eng [20%] | 400h |
| 57 | 8 | **300057 Mooring Maintenance** | 161d | 2007-02-01 | 2007-09-13 |  | 87d |  |  |  | 1152h |
| 58 | 8.1 | **M2 turnaround** | 55d | 2007-02-01 | 2007-04-18 |  | 193d |  |  |  | 576h |
| 59 | 8.1.1 | ME | 55d | 2007-02-01 | 2007-04-18 |  | 193d | 0d | start no earlier than 2007-02-01 | ME [9.1%] | 40h |
| 60 | 8.1.2 | Supp Eng | 55d | 2007-02-01 | 2007-04-18 | 59SS | 193d |  |  | Supp Eng [67.3%] | 296h |
| 61 | 8.1.3 | EE Tech | 55d | 2007-02-01 | 2007-04-18 | 59SS | 193d |  |  | EE Tech [18.2%] | 80h |
| 62 | 8.1.4 | ME Tech | 55d | 2007-02-01 | 2007-04-18 | 59SS | 193d |  |  | ME Tech [9.1%] | 40h |
| 63 | 8.1.5 | Machinist | 55d | 2007-02-01 | 2007-04-18 | 59SS | 193d |  |  | Machinist [27.3%] | 120h |
| 64 | 8.2 | **M1 turnaround** | 75d | 2007-06-01 | 2007-09-13 |  | 87d |  |  |  | 576h |
| 65 | 8.2.1 | ME | 75d | 2007-06-01 | 2007-09-13 |  | 87d | 0d | start no earlier than 2007-06-01 | ME [6.7%] | 40h |
| 66 | 8.2.2 | Supp Eng | 75d | 2007-06-01 | 2007-09-13 | 65SS | 87d |  |  | Supp Eng [49.3%] | 296h |
| 67 | 8.2.3 | EE Tech | 75d | 2007-06-01 | 2007-09-13 | 65SS | 87d |  |  | EE Tech [13.3%] | 80h |
| 68 | 8.2.4 | ME Tech | 75d | 2007-06-01 | 2007-09-13 | 65SS | 87d |  |  | ME Tech [6.7%] | 40h |
| 69 | 8.2.5 | Machinist | 75d | 2007-06-01 | 2007-09-13 | 65SS | 87d |  |  | Machinist [20%] | 120h |
| 70 | 9 | **300058-300078 DMO Maintenance** | 250d | 2007-01-02 | 2007-12-17 |  | 20d |  |  |  | 3512h |
| 71 | 9.1 | ME | 250d | 2007-01-02 | 2007-12-17 |  | 20d |  |  | ME [7.2%] | 144h |
| 72 | 9.2 | EE | 250d | 2007-01-02 | 2007-12-17 |  | 20d |  |  | EE [1.2%] | 24h |
| 73 | 9.3 | Supp Eng | 250d | 2007-01-02 | 2007-12-17 |  | 20d |  |  | Supp Eng [90%] | 1800h |
| 74 | 9.4 | EE Tech | 250d | 2007-01-02 | 2007-12-17 |  | 20d |  |  | EE Tech [11.6%] | 232h |
| 75 | 9.5 | ME Tech | 250d | 2007-01-02 | 2007-12-17 |  | 20d |  |  | ME Tech [15.6%] | 312h |
| 76 | 9.6 | Machinist | 250d | 2007-01-02 | 2007-12-17 |  | 20d |  |  | Machinist [50%] | 1000h |

| ID | WBS | Task | Duration | Start | Finish | Total slack | Constraint | Resources | Work |
| --- | --- | --- | --- | --- | --- | --- | --- | --- | --- |
| 77 | 10 | **500055 MDUC: ROV video annotation** | 250d | 2007-01-02 | 2007-12-17 | 20d |  |  | 240h |
| 78 | 10.1 | Supp Eng | 250d | 2007-01-02 | 2007-12-17 | 20d |  | Supp Eng [12%] | 240h |
| 79 | 11 | **500056 Joint Programs** | 250d | 2007-01-02 | 2007-12-17 | 20d |  |  | 520h |
| 80 | 11.1 | EE Tech | 250d | 2007-01-02 | 2007-12-17 | 20d |  | EE Tech [8%] | 160h |
| 81 | 11.2 | Supp Eng | 250d | 2007-01-02 | 2007-12-17 | 20d |  | Supp Eng [18%] | 360h |
| 82 | 12 | **600027 MOOS Mooring Project** | 250d | 2007-01-02 | 2007-12-17 | 20d |  |  | 5352h |
| 83 | 12.1 | EE | 250d | 2007-01-02 | 2007-12-17 | 20d |  | EE [102%] | 2040h |
| 84 | 12.2 | ME | 250d | 2007-01-02 | 2007-12-17 | 20d |  | ME [15.2%] | 304h |
| 85 | 12.3 | SE | 250d | 2007-01-02 | 2007-12-17 | 20d |  | SE [110.4%] | 2208h |
| 86 | 12.4 | EE Tech | 250d | 2007-01-02 | 2007-12-17 | 20d |  | EE Tech [20%] | 400h |
| 87 | 12.5 | ME Tech | 250d | 2007-01-02 | 2007-12-17 | 20d |  | ME Tech [9.2%] | 184h |
| 88 | 12.6 | Machinist | 250d | 2007-01-02 | 2007-12-17 | 20d |  | Machinist [10.8%] | 216h |
| 89 | 13 | **600034 Precision Control** | 174d | 2007-01-02 | 2007-08-31 | 96d |  |  | 520h |
| 90 | 13.1 | **Install SK and auto transect on Tiburon** | 174d | 2007-01-02 | 2007-08-31 | 96d |  |  | 120h |
| 91 | 13.1.1 | Supp Eng (Risi) | 20d | 2007-01-02 | 2007-01-29 | 250d |  | Supp Eng [25%] | 40h |
| 92 | 13.1.2 | Supp Eng (Risi) | 45d | 2007-07-02 | 2007-08-31 | 96d | start no earlier than 2007-07-02 | Supp Eng [22.2%] | 80h |
| 93 | 13.2 | **Terrain based localization** | 80d | 2007-01-02 | 2007-04-23 | 190d |  |  | 160h |
| 94 | 13.2.1 | SE (Algorithm dev) | 80d | 2007-01-02 | 2007-04-23 | 190d |  | SE [25%] | 160h |
| 95 | 13.3 | **Intervention task (ROV and mooring)** | 60d | 2007-06-04 | 2007-08-24 | 101d |  |  | 160h |
| 96 | 13.3.1 | SE | 60d | 2007-06-04 | 2007-08-24 | 101d | start no earlier than 2007-06-04 | SE [33.3%] | 160h |
| 97 | 13.4 | **Mosaic of non planar site** | 130d | 2007-01-02 | 2007-07-02 | 140d |  |  | 80h |
| 98 | 13.4.1 | Supp Eng (Brian Sc) | 130d | 2007-01-02 | 2007-07-02 | 140d |  | Supp Eng [7.7%] | 80h |
| 99 | 14 | **701520 NOSA** | 260d | 2007-01-02 | 2007-12-31 | 10d |  |  | 80h |
| 100 | 14.1 | Machinist | 260d | 2007-01-02 | 2007-12-31 | 10d |  | Machinist [3.8%] | 80h |

| ID | WBS | Task | Type | Duration | Start | Finish | Predecessors | Total slack | Free slack | Constraint | Resources | Work |
| --- | --- | --- | --- | --- | --- | --- | --- | --- | --- | --- | --- | --- |
| 101 | 15 | **708455 LOOKING** |  | 230d | 2007-01-02 | 2007-11-19 |  | 40d |  |  |  | 160h |
| 102 | 15.1 | SE |  | 230d | 2007-01-02 | 2007-11-19 |  | 40d |  |  | SE [8.7%] | 160h |
| 103 | 16 | **900026/701026 Sensors** |  | 260d | 2007-01-02 | 2007-12-31 |  | 10d |  |  |  | 1040h |
| 104 | 16.1 | **PUCK consortium, SIAM advisory** |  | 260d | 2007-01-02 | 2007-12-31 |  | 10d |  |  |  | 1040h |
| 105 | 16.1.1 | SE |  | 260d | 2007-01-02 | 2007-12-31 |  | 10d |  |  | SE [38.5%] | 800h |
| 106 | 16.1.2 | SE Tech |  | 260d | 2007-01-02 | 2007-12-31 |  | 10d |  |  | SE Tech [11.5%] | 240h |
| 107 | 16.2 | Complete SIAM/MARS Prototype | milestone | 0d | 2007-03-30 | 2007-03-30 |  | 207d |  | start no earlier than 2007-03-30 |  |  |
| 108 | 16.3 | Test on testbed | milestone | 0d | 2007-05-30 | 2007-05-30 |  | 164d |  | start no earlier than 2007-05-30 |  |  |
| 109 | 16.4 | Integrate and test with SSDS | milestone | 0d | 2007-07-31 | 2007-07-31 |  | 120d |  | start no earlier than 2007-07-31 |  |  |
| 110 | 16.5 | Deploy on MARS | milestone | 0d | 2007-09-28 | 2007-09-28 |  | 77d |  | start no earlier than 2007-09-28 |  |  |
| 111 | 17 | **900225 MARS** |  | 214d | 2007-01-02 | 2007-10-26 |  | 56d |  |  |  | 1640h |
| 112 | 17.1 | **Integration and test** |  | 130d | 2007-01-02 | 2007-07-02 |  | 140d |  |  |  | 1160h |
| 113 | 17.1.1 | EE |  | 130d | 2007-01-02 | 2007-07-02 |  | 140d |  |  | EE [38.5%] | 400h |
| 114 | 17.1.2 | ME |  | 130d | 2007-01-02 | 2007-07-02 |  | 140d |  |  | ME [38.5%] | 400h |
| 115 | 17.1.3 | EE Tech |  | 130d | 2007-01-02 | 2007-07-02 |  | 140d |  |  | EE Tech [15.4%] | 160h |
| 116 | 17.1.4 | ME Tech |  | 130d | 2007-01-02 | 2007-07-02 |  | 140d |  |  | ME Tech [11.5%] | 120h |
| 117 | 17.1.5 | Machinist |  | 130d | 2007-01-02 | 2007-07-02 |  | 140d |  |  | Machinist [7.7%] | 80h |
| 118 | 17.2 | Node Installation | milestone | 0d | 2007-07-16 | 2007-07-16 |  | 56d | 0d | start no earlier than 2007-07-16 |  |  |
| 119 | 17.3 | **Installation and commissioning** |  | 75d | 2007-07-16 | 2007-10-26 | 118 | 56d |  |  |  | 480h |
| 120 | 17.3.1 | EE |  | 75d | 2007-07-16 | 2007-10-26 |  | 56d | 0d | start no earlier than 2007-04-09 | EE [40%] | 240h |
| 121 | 17.3.2 | ME |  | 75d | 2007-07-16 | 2007-10-26 | 120SS | 56d |  |  | ME [40%] | 240h |
| 122 | 18 | **900392 BIOSA** |  | 195d | 2007-01-02 | 2007-10-01 |  | 75d |  |  |  | 1000h |
| 123 | 18.1 | **Implement internal data storage Ethernet communication** |  | 40d | 2007-01-02 | 2007-02-26 |  | 75d | 0d |  |  | 160h |
| 124 | 18.1.1 | Machinist |  | 40d | 2007-01-02 | 2007-02-26 |  | 75d |  |  | Machinist [50%] | 160h |

| ID | WBS | Task | Type | Duration | Start | Finish | Predecessors | Total slack | Free slack | Resources | Work |
| --- | --- | --- | --- | --- | --- | --- | --- | --- | --- | --- | --- |
| 125 | 18.2 | **Implement BIOSA internal fluorenscent sensor** |  | 40d | 2007-02-27 | 2007-04-23 | 123 | 75d | 0d |  | 360h |
| 126 | 18.2.1 | EE |  | 40d | 2007-02-27 | 2007-04-23 |  | 75d |  | EE [50%] | 160h |
| 127 | 18.2.2 | ME |  | 40d | 2007-02-27 | 2007-04-23 |  | 75d |  | ME [62.5%] | 200h |
| 128 | 18.3 | **Field test BIOSA internal fluorescence sensor** |  | 55d | 2007-04-24 | 2007-07-09 | 125 | 75d | 0d |  | 160h |
| 129 | 18.3.1 | Machinist |  | 55d | 2007-04-24 | 2007-07-09 |  | 75d |  | Machinist [36.4%] | 160h |
| 130 | 18.4 | **Implement BIOSA O2 , lab test fluorescence and O2 sensors** |  | 60d | 2007-07-09 | 2007-10-01 | 128 | 75d |  |  | 320h |
| 131 | 18.4.1 | EE |  | 60d | 2007-07-10 | 2007-10-01 |  | 75d |  | EE [33.3%] | 160h |
| 132 | 18.4.2 | ME |  | 60d | 2007-07-10 | 2007-10-01 |  | 75d |  | ME [33.3%] | 160h |
| 133 | 18.4.3 | Field test BIOSA with fluorescence and O2 sensor | milestone | 0d | 2007-07-09 | 2007-07-09 |  | 135d |  |  |  |
| 134 | 19 | **900403 Gulper** |  | 255d | 2007-01-02 | 2007-12-24 |  | 15d |  |  | 1184h |
| 135 | 19.1 | **Tools for samplers, 1 behavior written and tested** |  | 135d | 2007-01-02 | 2007-07-09 |  | 15d | 0d |  | 784h |
| 136 | 19.1.1 | ME |  | 135d | 2007-01-02 | 2007-07-09 |  | 15d |  | ME [22.2%] | 240h |
| 137 | 19.1.2 | EE |  | 135d | 2007-01-02 | 2007-07-09 |  | 15d |  | EE [14.8%] | 160h |
| 138 | 19.1.3 | SE |  | 135d | 2007-01-02 | 2007-07-09 |  | 15d |  | SE [14.8%] | 160h |
| 139 | 19.1.4 | ME Tech |  | 135d | 2007-01-02 | 2007-07-09 |  | 15d |  | ME Tech [14.8%] | 160h |
| 140 | 19.1.5 | Machinist |  | 135d | 2007-01-02 | 2007-07-09 |  | 15d |  | Machinist [5.9%] | 64h |
| 141 | 19.2 | **2 remaining behaviors written and tested** |  | 45d | 2007-07-10 | 2007-09-10 | 135 | 15d | 0d |  | 240h |
| 142 | 19.2.1 | EE |  | 45d | 2007-07-10 | 2007-09-10 |  | 15d |  | EE [22.2%] | 80h |
| 143 | 19.2.2 | SE |  | 45d | 2007-07-10 | 2007-09-10 |  | 15d |  | SE [44.4%] | 160h |
| 144 | 19.3 | **Routine operations, publications** |  | 75d | 2007-09-11 | 2007-12-24 | 141 | 15d |  |  | 160h |
| 145 | 19.3.1 | EE |  | 75d | 2007-09-11 | 2007-12-24 |  | 15d |  | EE [13.3%] | 80h |
| 146 | 19.3.2 | SE |  | 75d | 2007-09-11 | 2007-12-24 |  | 15d |  | SE [6.7%] | 40h |
| 147 | 19.3.3 | ME Tech |  | 75d | 2007-09-11 | 2007-12-24 |  | 15d |  | EE Tech [6.7%] | 40h |
| 148 | 20 | **900424 Seafloor mapping** |  | 80d | 2007-01-02 | 2007-04-23 |  | 190d |  |  | 320h |
| 149 | 20.1 | **Finish testing obstacle avoidance sonar** |  | 80d | 2007-01-02 | 2007-04-23 |  | 190d |  |  | 320h |
| 150 | 20.1.1 | SE |  | 80d | 2007-01-02 | 2007-04-23 |  | 190d |  | SE [50%] | 320h |

| ID | WBS | Task | Duration | Start | Finish | Predecessors | Total slack | Free slack | Resources | Work |
| --- | --- | --- | --- | --- | --- | --- | --- | --- | --- | --- |
| 151 | 21 | **900507 Eddy flux** | 260d | 2007-01-02 | 2007-12-31 |  | 10d |  |  | 80h |
| 152 | 21.1 | SE | 260d | 2007-01-02 | 2007-12-31 |  | 10d |  | SE [1.9%] | 40h |
| 153 | 21.2 | Machinist | 260d | 2007-01-02 | 2007-12-31 |  | 10d |  | Machinist [1.9%] | 40h |
| 154 | 22 | **900515 IODP Boreholes** | 260d | 2007-01-02 | 2007-12-31 |  | 10d |  |  | 312h |
| 155 | 22.1 | ME (no driving milestones) | 260d | 2007-01-02 | 2007-12-31 |  | 10d |  | ME [15%] | 312h |
| 156 | 23 | **900601 Sensor Technology Marine Nitrogen Cycle** | 260d | 2007-01-02 | 2007-12-31 |  | 10d |  |  | 240h |
| 157 | 23.1 | Machinist | 260d | 2007-01-02 | 2007-12-31 |  | 10d |  | Machinist [11.5%] | 240h |
| 158 | 24 | **900606 Chemical Sensors** | 260d | 2007-01-02 | 2007-12-31 |  | 10d |  |  | 400h |
| 159 | 24.1 | Machinist | 260d | 2007-01-02 | 2007-12-31 |  | 10d |  | Machinist [11.5%] | 240h |
| 160 | 24.2 | EE Tech | 260d | 2007-01-02 | 2007-12-31 |  | 10d |  | EE Tech [3.8%] | 80h |
| 161 | 24.3 | ME Tech | 260d | 2007-01-02 | 2007-12-31 |  | 10d |  | ME Tech [3.8%] | 80h |
| 162 | 25 | **703506 ASTEP D-ESP** | 160d | 2007-01-02 | 2007-08-13 |  | 110d |  |  | 2984h |
| 163 | 25.1 | **Deep water sampler ESP depth profile with ROV Ventana** | 42d | 2007-01-02 | 2007-02-28 |  | 228d |  |  | 824h |
| 164 | 25.1.1 | EE(Scott) | 42d | 2007-01-02 | 2007-02-28 |  | 228d |  | EE (Scott) [71.4%] | 240h |
| 165 | 25.1.2 | SE | 42d | 2007-01-02 | 2007-02-28 |  | 228d |  | SE [71.4%] | 240h |
| 166 | 25.1.3 | ME | 42d | 2007-01-02 | 2007-02-28 |  | 228d |  | ME [42.9%] | 144h |
| 167 | 25.1.4 | ME Tech | 42d | 2007-01-02 | 2007-02-28 |  | 228d |  | EE Tech [47.6%] | 160h |
| 168 | 25.1.5 | Machinist | 42d | 2007-01-02 | 2007-02-28 |  | 228d |  | Machinist [11.9%] | 40h |
| 169 | 25.2 | **CDR for LLNL PCR** | 60d | 2007-01-02 | 2007-03-26 |  | 110d | 0d |  | 1024h |
| 170 | 25.2.1 | EE(Scott) | 60d | 2007-01-02 | 2007-03-26 |  | 110d |  | EE (Scott) [33.3%] | 160h |
| 171 | 25.2.2 | SE | 60d | 2007-01-02 | 2007-03-26 |  | 110d |  | SE [58.3%] | 280h |
| 172 | 25.2.3 | ME | 60d | 2007-01-02 | 2007-03-26 |  | 110d |  | ME [38.3%] | 184h |
| 173 | 25.2.4 | ME Tech | 60d | 2007-01-02 | 2007-03-26 |  | 110d |  | ME Tech [83.3%] | 400h |
| 174 | 25.3 | **Readiness review for 3K sampler** | 25d | 2007-03-27 | 2007-04-30 | 169 | 185d |  |  | 160h |
| 175 | 25.3.1 | EE(Scott) | 25d | 2007-03-27 | 2007-04-30 |  | 185d |  | EE (Scott) [20%] | 40h |
| 176 | 25.3.2 | SE | 25d | 2007-03-27 | 2007-04-30 |  | 185d |  | SE [20%] | 40h |
| 177 | 25.3.3 | ME | 25d | 2007-03-27 | 2007-04-30 |  | 185d |  | ME [20%] | 40h |
| 178 | 25.3.4 | ME Tech | 25d | 2007-03-27 | 2007-04-30 |  | 185d |  | ME Tech [20%] | 40h |

| ID | WBS | Task | Duration | Start | Finish | Predecessors | Total slack | Free slack | Resources | Work |
| --- | --- | --- | --- | --- | --- | --- | --- | --- | --- | --- |
| 179 | 25.4 | **Microfluidics benchtop PCR unit** | 100d | 2007-03-27 | 2007-08-13 | 169 | 110d |  |  | 976h |
| 180 | 25.4.1 | EE(Scott) | 100d | 2007-03-27 | 2007-08-13 |  | 110d |  | EE (Scott) [10%] | 80h |
| 181 | 25.4.2 | SE | 100d | 2007-03-27 | 2007-08-13 |  | 110d |  | SE [36%] | 288h |
| 182 | 25.4.3 | ME | 100d | 2007-03-27 | 2007-08-13 |  | 110d | 0d | ME [20%] | 160h |
| 183 | 25.4.4 | ME Tech | 100d | 2007-03-27 | 2007-08-13 |  | 110d |  | ME Tech [40%] | 320h |
| 184 | 25.4.5 | EE Tech | 100d | 2007-03-27 | 2007-08-13 |  | 110d |  | EE Tech [10%] | 80h |
| 185 | 25.4.6 | Machinist | 60d | 2007-05-22 | 2007-08-13 | 182FS-60d | 110d |  | Machinist [10%] | 48h |
| 186 | 26 | **800560 MEGA** | 247d | 2007-01-02 | 2007-12-12 |  | 23d |  |  | 3256h |
| 187 | 26.1 | **PDR for fluidic system** | 42d | 2007-01-02 | 2007-02-28 |  | 23d | 0d |  | 928h |
| 188 | 26.1.1 | EE (Scott) | 42d | 2007-01-02 | 2007-02-28 |  | 23d |  | EE (Scott) [119%] | 400h |
| 189 | 26.1.2 | SE | 42d | 2007-01-02 | 2007-02-28 |  | 23d |  | SE [23.8%] | 80h |
| 190 | 26.1.3 | ME | 42d | 2007-01-02 | 2007-02-28 |  | 23d |  | ME [109.5%] | 368h |
| 191 | 26.1.4 | ME Tech | 42d | 2007-01-02 | 2007-02-28 |  | 23d |  | ME Tech [23.8%] | 80h |
| 192 | 26.2 | **CDR for fluidics system** | 85d | 2007-03-01 | 2007-06-27 | 187 | 23d | 0d |  | 1792h |
| 193 | 26.2.1 | EE (Scott) | 85d | 2007-03-01 | 2007-06-27 |  | 23d |  | EE (Scott) [58.8%] | 400h |
| 194 | 26.2.2 | SE | 85d | 2007-03-01 | 2007-06-27 |  | 23d |  | SE [35.3%] | 240h |
| 195 | 26.2.3 | ME | 85d | 2007-03-01 | 2007-06-27 |  | 23d |  | ME [47.1%] | 320h |
| 196 | 26.2.4 | ME Tech | 85d | 2007-03-01 | 2007-06-27 |  | 23d |  | ME Tech [94.1%] | 640h |
| 197 | 26.2.5 | EE Tech | 85d | 2007-03-01 | 2007-06-27 |  | 23d |  | EE Tech [15.3%] | 104h |
| 198 | 26.2.6 | Machinist | 85d | 2007-03-01 | 2007-06-27 |  | 23d |  | Machinist [12.9%] | 88h |
| 199 | 26.3 | **First tests using optical Walt array** | 120d | 2007-06-28 | 2007-12-12 | 192 | 23d |  |  | 536h |
| 200 | 26.3.1 | EE (Scott) | 120d | 2007-06-28 | 2007-12-12 |  | 23d |  | EE (Scott) [16.7%] | 160h |
| 201 | 26.3.2 | SE | 120d | 2007-06-28 | 2007-12-12 |  | 23d |  | SE [22.5%] | 216h |
| 202 | 26.3.3 | ME | 120d | 2007-06-28 | 2007-12-12 |  | 23d |  | ME [8.3%] | 80h |
| 203 | 26.3.4 | ME Tech | 120d | 2007-06-28 | 2007-12-12 |  | 23d |  | ME Tech [8.3%] | 80h |

| ID | WBS | Task | Duration | Start | Finish | Predecessors | Total slack | Free slack | Resources | Work |
| --- | --- | --- | --- | --- | --- | --- | --- | --- | --- | --- |
| 204 | 27 | **708602 C-MORE** | 260d | 2007-01-02 | 2007-12-31 |  | 10d |  |  | 240h |
| 205 | 27.1 | **Functional requirements** | 130d | 2007-01-02 | 2007-07-02 |  | 10d | 0d |  | 40h |
| 206 | 27.1.1 | SE | 130d | 2007-01-02 | 2007-07-02 |  | 10d |  | SE [3.8%] | 40h |
| 207 | 27.2 | **Usage scenarios and specifications** | 130d | 2007-07-03 | 2007-12-31 | 205 | 10d |  |  | 200h |
| 208 | 27.2.1 | EE (Scott) | 130d | 2007-07-03 | 2007-12-31 |  | 10d |  | EE (Scott) [3.8%] | 40h |
| 209 | 27.2.2 | SE | 130d | 2007-07-03 | 2007-12-31 |  | 10d |  | SE [7.7%] | 80h |
| 210 | 27.2.3 | ME | 130d | 2007-07-03 | 2007-12-31 |  | 10d |  | ME [7.7%] | 80h |
| 211 | 28 | **900612 MBARI ESP Applications** | 255d | 2007-01-02 | 2007-12-24 |  | 15d |  |  | 2368h |
| 212 | 28.1 | **Two surface deployments with multi threaded protocols** | 90d | 2007-01-02 | 2007-05-07 |  | 180d |  |  | 320h |
| 213 | 28.1.1 | EE (Scott) | 90d | 2007-01-02 | 2007-05-07 |  | 180d |  | EE (Scott) [5.6%] | 40h |
| 214 | 28.1.2 | SE | 90d | 2007-01-02 | 2007-05-07 |  | 180d |  | SE [33.3%] | 240h |
| 215 | 28.1.3 | ME | 90d | 2007-01-02 | 2007-05-07 |  | 180d |  | ME [5.6%] | 40h |
| 216 | 28.2 | **Software GUI control and monitoring CDR and RR** | 175d | 2007-01-02 | 2007-09-03 |  | 95d |  |  | 800h |
| 217 | 28.2.1 | SE | 175d | 2007-01-02 | 2007-09-03 |  | 95d |  | SE [57.1%] | 800h |
| 218 | 28.3 | **Data archival system for array images CDR and RR** | 175d | 2007-01-02 | 2007-09-03 |  | 15d | 0d |  | 640h |
| 219 | 28.3.1 | SE | 175d | 2007-01-02 | 2007-09-03 |  | 15d |  | SE [45.7%] | 640h |
| 220 | 28.4 | **Surface deployment (possibly networked)** | 45d | 2007-09-04 | 2007-11-05 | 218 | 15d | 0d |  | 328h |
| 221 | 28.4.1 | SE | 45d | 2007-09-04 | 2007-11-05 |  | 15d |  | SE [91.1%] | 328h |
| 222 | 28.5 | **PUCK development** | 35d | 2007-11-06 | 2007-12-24 | 220 | 15d |  |  | 280h |
| 223 | 28.5.1 | EE (Scott) | 35d | 2007-11-06 | 2007-12-24 |  | 15d |  | EE (Scott) [14.3%] | 40h |
| 224 | 28.5.2 | ME | 35d | 2007-11-06 | 2007-12-24 |  | 15d |  | ME [14.3%] | 40h |
| 225 | 28.5.3 | ME Tech | 35d | 2007-11-06 | 2007-12-24 |  | 15d |  | ME Tech [42.9%] | 120h |
| 226 | 28.5.4 | Machinist | 35d | 2007-11-06 | 2007-12-24 |  | 15d |  | Machinist [28.6%] | 80h |
| 227 | 29 | **900612 ESP Technology Transfer** | 200d | 2007-01-02 | 2007-10-08 |  | 70d |  |  | 912h |
| 228 | 29.1 | **Readiness review** | 175d | 2007-01-02 | 2007-09-03 |  | 70d | 0d |  | 792h |
| 229 | 29.1.1 | EE (Scott) | 175d | 2007-01-02 | 2007-09-03 |  | 70d |  | EE (Scott) [8.6%] | 120h |
| 230 | 29.1.2 | SE | 175d | 2007-01-02 | 2007-09-03 |  | 70d |  | SE [9.1%] | 128h |
| 231 | 29.1.3 | ME | 175d | 2007-01-02 | 2007-09-03 |  | 70d |  | ME [2.9%] | 40h |
| 232 | 29.1.4 | EE Tech | 175d | 2007-01-02 | 2007-09-03 |  | 70d |  | EE Tech [7.4%] | 104h |
| 233 | 29.1.5 | ME Tech | 175d | 2007-01-02 | 2007-09-03 |  | 70d |  | ME Tech [28.6%] | 400h |

| ID | WBS | Task | Duration | Start | Finish | Predecessors | Total slack | Free slack | Constraint | Resources | Work |
| --- | --- | --- | --- | --- | --- | --- | --- | --- | --- | --- | --- |
| 234 | 29.2 | **Workshop** | 5d | 2007-10-02 | 2007-10-08 | 228FS+20d | 70d |  |  |  | 120h |
| 235 | 29.2.1 | EE (Scott) | 5d | 2007-10-02 | 2007-10-08 |  | 70d |  |  | EE (Scott) | 40h |
| 236 | 29.2.2 | SE | 5d | 2007-10-02 | 2007-10-08 |  | 70d |  |  | SE | 40h |
| 237 | 29.2.3 | ME | 5d | 2007-10-02 | 2007-10-08 |  | 70d |  |  | ME | 40h |
| 238 | 30 | **900613 ESP Probe Chemistry** | 20d | 2007-10-01 | 2007-10-26 |  | 56d |  |  |  | 120h |
| 239 | 30.1 | **Transition to new array support** | 20d | 2007-10-01 | 2007-10-26 |  | 56d |  |  |  | 120h |
| 240 | 30.1.1 | ME Tech | 20d | 2007-10-01 | 2007-10-26 |  | 56d | 0d | start no earlier than 2007-10-01 | ME Tech [25%] | 40h |
| 241 | 30.1.2 | Supp Eng | 20d | 2007-10-01 | 2007-10-26 | 240SS | 56d |  |  | Supp Eng [50%] | 80h |
| 242 | 31 | **900617 MRS** | 119d? | 2007-01-02 | 2007-06-15 |  | 151d |  |  |  | 784h |
| 243 | 31.1 | ME (16 approved but may be done by Supp Eng)) | 1d? | 2007-01-02 | 2007-01-02 |  | 269d |  |  |  | 128h |
| 244 | 31.2 | **Respirometer modifications** | 30d | 2007-01-02 | 2007-02-12 |  | 151d | 0d |  |  | 232h |
| 245 | 31.2.1 | Supp Eng | 30d | 2007-01-02 | 2007-02-12 |  | 151d |  |  | Supp Eng [16.7%] | 40h |
| 246 | 31.2.2 | Machinist | 30d | 2007-01-02 | 2007-02-12 |  | 151d |  |  | Machinist [66.7%] | 160h |
| 247 | 31.2.3 | ME Tech | 30d | 2007-01-02 | 2007-02-12 |  | 151d |  |  | ME Tech [6.7%] | 16h |
| 248 | 31.2.4 | EE Tech | 30d | 2007-01-02 | 2007-02-12 |  | 151d |  |  | EE Tech [6.7%] | 16h |
| 249 | 31.3 | **Sub surface MRS mooring design** | 20d | 2007-02-13 | 2007-03-12 | 244 | 151d | 0d |  |  | 32h |
| 250 | 31.3.1 | Supp Eng | 20d | 2007-02-13 | 2007-03-12 |  | 151d |  |  | Supp Eng [20%] | 32h |
| 251 | 31.4 | **Tank and shallow water testing of MRS mooring** | 25d | 2007-03-13 | 2007-04-16 | 249 | 151d | 0d |  |  | 128h |
| 252 | 31.4.1 | Supp Eng | 25d | 2007-03-13 | 2007-04-16 |  | 151d |  |  | Supp Eng [32%] | 64h |
| 253 | 31.4.2 | ME Tech | 25d | 2007-03-13 | 2007-04-16 |  | 151d |  |  | ME Tech [8%] | 16h |
| 254 | 31.4.3 | Machinist | 25d | 2007-03-13 | 2007-04-16 |  | 151d |  |  | Machinist [24%] | 48h |
| 255 | 31.5 | **Deploy full length MRS mooring** | 20d | 2007-04-17 | 2007-05-14 | 251 | 151d | 0d |  |  | 224h |
| 256 | 31.5.1 | Supp Eng | 20d | 2007-04-17 | 2007-05-14 |  | 151d |  |  | Supp Eng [25%] | 40h |
| 257 | 31.5.2 | ME Tech | 20d | 2007-04-17 | 2007-05-14 |  | 151d |  |  | ME Tech [15%] | 24h |
| 258 | 31.5.3 | Machinist | 20d | 2007-04-17 | 2007-05-14 |  | 151d |  |  | Machinist | 160h |

| ID | WBS | Task | Duration | Start | Finish | Predecessors | Total slack | Free slack | Constraint | Resources | Work |
| --- | --- | --- | --- | --- | --- | --- | --- | --- | --- | --- | --- |
| 259 | 31.6 | **Deploy MRS on mooring** | 24d | 2007-05-15 | 2007-06-15 | 255 | 151d |  |  |  | 40h |
| 260 | 31.6.1 | Supp Eng | 24d | 2007-05-15 | 2007-06-15 |  | 151d |  |  | Supp Eng [20.8%] | 40h |
| 261 | 32 | **900618 Mining VARS** | 200d | 2007-01-02 | 2007-10-08 |  | 70d |  |  |  | 600h |
| 262 | 32.1 | **Complete visualization** | 60d | 2007-01-02 | 2007-03-26 |  | 70d | 0d |  |  | 240h |
| 263 | 32.1.1 | SE | 60d | 2007-01-02 | 2007-03-26 |  | 70d |  |  | SE [50%] | 240h |
| 264 | 32.2 | **Statistical analysis** | 140d | 2007-03-27 | 2007-10-08 | 262 | 70d |  |  |  | 360h |
| 265 | 32.2.1 | SE | 140d | 2007-03-27 | 2007-10-08 |  | 70d |  |  | SE [21.4%] | 240h |
| 266 | 32.2.2 | Supp Eng | 140d | 2007-03-27 | 2007-10-08 |  | 70d |  |  | Supp Eng [10.7%] | 120h |
| 267 | 33 | **900622 Pelagic-Benthic Coupling and Carbon Cycle** | 110d | 2007-01-02 | 2007-06-04 |  | 160d |  |  |  | 704h |
| 268 | 33.1 | **Cruise 3 transect stations** | 40d | 2007-01-02 | 2007-02-26 |  | 160d | 0d |  |  | 64h |
| 269 | 33.1.1 | EE | 40d | 2007-01-02 | 2007-02-26 |  | 160d |  |  | EE [20%] | 64h |
| 270 | 33.2 | **Interface sedimentation sensor/time lapse camera for MOOS** | 70d | 2007-02-27 | 2007-06-04 | 268 | 160d |  |  |  | 640h |
| 271 | 33.2.1 | EE | 70d | 2007-02-27 | 2007-06-04 |  | 160d |  |  | EE [28.6%] | 160h |
| 272 | 33.2.2 | SE | 70d | 2007-02-27 | 2007-06-04 |  | 160d |  |  | SE [57.1%] | 320h |
| 273 | 33.2.3 | ME | 70d | 2007-02-27 | 2007-06-04 |  | 160d |  |  | ME [14.3%] | 80h |
| 274 | 33.2.4 | ME Tech | 70d | 2007-02-27 | 2007-06-04 |  | 160d |  |  | ME Tech [14.3%] | 80h |
| 275 | 34 | **900632 Observing pH Shift in Upper Ocean** | 130d | 2007-01-02 | 2007-07-02 |  | 140d |  |  |  | 80h |
| 276 | 34.1 | **Develop FRR sensor for measurement photosynthetic responses** | 60d | 2007-01-02 | 2007-03-26 |  | 140d | 0d |  |  | 40h |
| 277 | 34.1.1 | Machinist | 60d | 2007-01-02 | 2007-03-26 |  | 140d |  |  | Machinist [8.3%] | 40h |
| 278 | 34.2 | **Two vessel pH stat for ship board operation** | 70d | 2007-03-27 | 2007-07-02 | 276 | 140d |  |  |  | 40h |
| 279 | 34.2.1 | Machinist | 70d | 2007-03-27 | 2007-07-02 |  | 140d |  |  | Machinist [7.1%] | 40h |
| 280 | 35 | **900638 Research Engineering Sensor Program** | 214d | 2007-01-02 | 2007-10-26 |  | 56d |  |  |  | 520h |
| 281 | 35.1 | **Assemble boards and instruments** | 214d | 2007-01-02 | 2007-10-26 |  | 56d |  |  |  | 520h |
| 282 | 35.1.1 | Machinist | 40d | 2007-05-01 | 2007-06-25 |  | 145d |  | start no earlier than 2007-05-01 | Machinist [25%] | 80h |
| 283 | 35.1.2 | Machinist | 40d | 2007-09-03 | 2007-10-26 |  | 56d |  | start no earlier than 2007-09-03 | Machinist [37.5%] | 120h |
| 284 | 35.1.3 | ME | 20d | 2007-05-01 | 2007-05-28 |  | 165d |  | start no earlier than 2007-05-01 | ME [50%] | 80h |
| 285 | 35.1.4 | ME | 40d | 2007-09-03 | 2007-10-26 |  | 56d |  | start no earlier than 2007-09-03 | ME [25%] | 80h |
| 286 | 35.1.5 | EE Tech | 20d | 2007-01-02 | 2007-01-29 |  | 250d |  |  | EE Tech [50%] | 80h |
| 287 | 35.1.6 | EE Tech | 40d | 2007-04-02 | 2007-05-25 |  | 166d |  | start no earlier than 2007-04-02 | EE Tech [25%] | 80h |

| ID | WBS | Task | Type | Duration | Start | Finish | Predecessors | Total slack | Free slack | Constraint | Resources | Work |
| --- | --- | --- | --- | --- | --- | --- | --- | --- | --- | --- | --- | --- |
| 288 | 36 | **900645/701647 MMI** |  | 260d | 2007-01-02 | 2007-12-31 |  | 10d |  |  |  | 592h |
| 289 | 36.1 | SE |  | 260d | 2007-01-02 | 2007-12-31 |  | 10d |  |  | SE [28.5%] | 592h |
| 290 | 37 | **900703 Benthic Biology** |  | 260d | 2007-01-02 | 2007-12-31 |  | 10d |  |  |  | 344h |
| 291 | 37.1 | Machinist |  | 260d | 2007-01-02 | 2007-12-31 |  | 10d |  |  | Machinist [3.8%] | 80h |
| 292 | 37.2 | Supp Eng |  | 260d | 2007-01-02 | 2007-12-31 |  | 10d |  |  | Supp Eng [12.7%] | 264h |
| 293 | 38 | **900719 FOCE** |  | 200d | 2007-02-14 | 2007-11-20 |  | 39d |  |  |  | 1168h |
| 294 | 38.1 | Concept for flow control | milestone | 0d | 2007-02-14 | 2007-02-14 |  | 39d | 0d | start no earlier than 2007-02-14 |  |  |
| 295 | 38.2 | **Construct test samples** |  | 45d | 2007-02-14 | 2007-04-17 | 294 | 39d | 0d |  |  | 320h |
| 296 | 38.2.1 | ME |  | 45d | 2007-02-14 | 2007-04-17 |  | 39d |  |  | ME [11.1%] | 40h |
| 297 | 38.2.2 | ME Tech |  | 45d | 2007-02-14 | 2007-04-17 |  | 39d |  |  | ME Tech [22.2%] | 80h |
| 298 | 38.2.3 | EE Tech |  | 45d | 2007-02-14 | 2007-04-17 |  | 39d |  |  | EE Tech [22.2%] | 80h |
| 299 | 38.2.4 | Machinist |  | 45d | 2007-02-14 | 2007-04-17 |  | 39d |  |  | Machinist [33.3%] | 120h |
| 300 | 38.3 | **Flume testing** |  | 45d | 2007-04-18 | 2007-06-19 | 295 | 39d | 0d |  |  | 208h |
| 301 | 38.3.1 | ME Tech |  | 45d | 2007-04-18 | 2007-06-19 |  | 39d |  |  | ME Tech [33.3%] | 120h |
| 302 | 38.3.2 | EE Tech |  | 45d | 2007-04-18 | 2007-06-19 |  | 39d |  |  | EE Tech [22.2%] | 80h |
| 303 | 38.3.3 | Machinist |  | 45d | 2007-04-18 | 2007-06-19 |  | 39d |  |  | Machinist [2.2%] | 8h |
| 304 | 38.4 | **Segment build and test** |  | 110d | 2007-06-20 | 2007-11-20 | 300 | 39d |  |  |  | 640h |
| 305 | 38.4.1 | SE |  | 110d | 2007-06-20 | 2007-11-20 |  | 39d |  |  | SE [9.1%] | 80h |
| 306 | 38.4.2 | ME Tech |  | 110d | 2007-06-20 | 2007-11-20 |  | 39d |  |  | ME Tech [32.7%] | 288h |
| 307 | 38.4.3 | Machinist |  | 110d | 2007-06-20 | 2007-11-20 |  | 39d |  |  | Machinist [30.9%] | 272h |
| 308 | 39 | **900720 Onboard Decision Making for Platform C&C** |  | 260d | 2007-01-02 | 2007-12-31 |  | 10d |  |  |  | 440h |
| 309 | 39.1 | SE |  | 260d | 2007-01-02 | 2007-12-31 |  | 10d |  |  | SE [21.2%] | 440h |
| 310 | 40 | **900721 GIS Upgrade** |  | 260d | 2007-01-02 | 2007-12-31 |  | 10d |  |  |  | 240h |
| 311 | 40.1 | Supp Eng |  | 260d | 2007-01-02 | 2007-12-31 |  | 10d |  |  | Supp Eng [11.5%] | 240h |

| ID | WBS | Task | Type | Duration | Start | Finish | Predecessors | Total slack | Free slack | Constraint | Resources | Work |
| --- | --- | --- | --- | --- | --- | --- | --- | --- | --- | --- | --- | --- |
| 312 | 41 | **900723 Wave Energy Extraction VP Applications** |  | 105d | 2007-05-02 | 2007-09-25 |  | 79d |  |  |  | 760h |
| 313 | 41.1 | **Analysis testing available energy** |  | 75d | 2007-05-02 | 2007-08-14 |  | 79d | 0d |  |  | 200h |
| 314 | 41.1.1 | EE |  | 75d | 2007-05-02 | 2007-08-14 |  | 79d | 0d | start no earlier than 2007-05-02 | EE [6.7%] | 40h |
| 315 | 41.1.2 | ME |  | 75d | 2007-05-02 | 2007-08-14 | 314SS | 79d |  | start no earlier than 2007-05-01 | ME [20%] | 120h |
| 316 | 41.1.3 | ME Tech |  | 75d | 2007-05-02 | 2007-08-14 | 314SS | 79d |  |  | ME Tech [6.7%] | 40h |
| 317 | 41.2 | **Analysis testing conversion technique** |  | 75d | 2007-05-02 | 2007-08-14 |  | 79d | 0d |  |  | 440h |
| 318 | 41.2.1 | EE |  | 75d | 2007-05-02 | 2007-08-14 |  | 79d | 0d | start no earlier than 2007-05-02 | EE [26.7%] | 160h |
| 319 | 41.2.2 | ME |  | 75d | 2007-05-02 | 2007-08-14 | 318SS | 79d |  |  | ME [13.3%] | 80h |
| 320 | 41.2.3 | EE Tech |  | 75d | 2007-05-02 | 2007-08-14 | 318SS | 79d |  |  | EE Tech [13.3%] | 80h |
| 321 | 41.2.4 | ME Tech |  | 75d | 2007-05-02 | 2007-08-14 | 318SS | 79d |  |  | ME Tech [6.7%] | 40h |
| 322 | 41.2.5 | Machinist |  | 75d | 2007-05-02 | 2007-08-14 |  | 79d |  | start no earlier than 2007-05-02 | Machinist [13.3%] | 80h |
| 323 | 41.3 | **Collaboration exploration** |  | 30d | 2007-08-06 | 2007-09-14 |  | 86d |  |  |  | 40h |
| 324 | 41.3.1 | ME |  | 30d | 2007-08-06 | 2007-09-14 |  | 86d |  | start no earlier than 2007-08-06 | ME [16.7%] | 40h |
| 325 | 41.4 | **Concept design review** |  | 30d | 2007-08-15 | 2007-09-25 | 317, 313 | 79d |  |  |  | 80h |
| 326 | 41.4.1 | EE |  | 30d | 2007-08-15 | 2007-09-25 |  | 79d | 0d | start no earlier than 2007-07-02 | EE [16.7%] | 40h |
| 327 | 41.4.2 | ME |  | 30d | 2007-08-15 | 2007-09-25 | 326SS | 79d |  |  | ME [16.7%] | 40h |
| 328 | 41.4.3 | Concept Design Review | milestone | 0d | 2007-08-15 | 2007-08-15 |  | 109d |  | start no earlier than 2007-08-15 |  |  |
| 329 | 42 | **900725 Ocean Carbon N2 Cycling in 21st Century** |  | 260d | 2007-01-02 | 2007-12-31 |  | 10d |  |  |  | 240h |
| 330 | 42.1 | ME |  | 260d | 2007-01-02 | 2007-12-31 |  | 10d |  |  | ME [7.7%] | 160h |
| 331 | 42.2 | SE (Wheeler) |  | 260d | 2007-01-02 | 2007-12-31 |  | 10d |  |  | SE [3.8%] | 80h |
| 332 | 43 | **900727 MARS O&M** |  | 105d | 2007-08-01 | 2007-12-25 |  | 14d |  |  |  | 440h |
| 333 | 43.1 | EE |  | 105d | 2007-08-01 | 2007-12-25 |  | 14d | 0d | start no earlier than 2007-08-01 | EE [9.5%] | 80h |
| 334 | 43.2 | ME |  | 105d | 2007-08-01 | 2007-12-25 | 333SS | 14d |  |  | ME [28.6%] | 240h |
| 335 | 43.3 | SE |  | 105d | 2007-08-01 | 2007-12-25 | 333SS | 14d |  |  | SE [14.3%] | 120h |

| ID | WBS | Task | Type | Duration | Start | Finish | Predecessors | Total slack | Free slack | Constraint | Resources | Work |
| --- | --- | --- | --- | --- | --- | --- | --- | --- | --- | --- | --- | --- |
| 336 | 44 | **900728 CSO** |  | 259d | 2007-01-02 | 2007-12-28 |  | 11d |  |  |  | 6000h |
| 337 | 44.1 | **Requirements Definition** |  | 60d | 2007-01-02 | 2007-03-26 |  | 210d |  |  |  | 1000h |
| 338 | 44.1.1 | EE |  | 60d | 2007-01-02 | 2007-03-26 |  | 210d |  |  | EE [75%] | 360h |
| 339 | 44.1.2 | SE |  | 60d | 2007-01-02 | 2007-03-26 |  | 210d |  |  | SE [75%] | 360h |
| 340 | 44.1.3 | ME (Andy) |  | 60d | 2007-01-02 | 2007-03-26 |  | 210d |  |  | ME (Andy) [58.3%] | 280h |
| 341 | 44.2 | **Technology exploration** |  | 60d | 2007-01-02 | 2007-03-26 |  | 210d |  |  |  | 760h |
| 342 | 44.2.1 | EE |  | 60d | 2007-01-02 | 2007-03-26 |  | 210d |  |  | EE | 480h |
| 343 | 44.2.2 | SE |  | 60d | 2007-01-02 | 2007-03-26 |  | 210d |  |  | SE [33.3%] | 160h |
| 344 | 44.2.3 | ME (Andy) |  | 60d | 2007-01-02 | 2007-03-26 |  | 210d |  |  | ME (Andy) [25%] | 120h |
| 345 | 44.3 | **Prepare RFP** |  | 75d | 2007-04-02 | 2007-07-13 |  | 11d | 0d |  |  | 1680h |
| 346 | 44.3.1 | EE |  | 75d | 2007-04-02 | 2007-07-13 |  | 11d | 0d | start no earlier than 2007-04-02 | EE [80%] | 480h |
| 347 | 44.3.2 | SE |  | 75d | 2007-04-02 | 2007-07-13 | 346SS | 11d |  |  | SE [120%] | 720h |
| 348 | 44.3.3 | ME (Andy) |  | 75d | 2007-04-02 | 2007-07-13 | 346SS | 11d |  |  | ME (Andy) [80%] | 480h |
| 349 | 44.4 | **Prepare for OOI PDR** |  | 50d | 2007-07-16 | 2007-09-21 | 345 | 11d | 0d |  |  | 1240h |
| 350 | 44.4.1 | EE |  | 50d | 2007-07-16 | 2007-09-21 |  | 11d |  |  | EE [120%] | 480h |
| 351 | 44.4.2 | SE |  | 50d | 2007-07-16 | 2007-09-21 |  | 11d |  |  | SE [120%] | 480h |
| 352 | 44.4.3 | ME (Andy) |  | 50d | 2007-07-16 | 2007-09-21 |  | 11d |  |  | ME (Andy) [70%] | 280h |
| 353 | 44.5 | **Prepare for OOI CDR** |  | 70d | 2007-09-24 | 2007-12-28 | 349 | 11d |  |  |  | 1320h |
| 354 | 44.5.1 | EE |  | 70d | 2007-09-24 | 2007-12-28 |  | 11d |  |  | EE [85.7%] | 480h |
| 355 | 44.5.2 | SE |  | 70d | 2007-09-24 | 2007-12-28 |  | 11d |  |  | SE [85.7%] | 480h |
| 356 | 44.5.3 | ME (Andy) |  | 70d | 2007-09-24 | 2007-12-28 |  | 11d |  |  | ME (Andy) [64.3%] | 360h |
| 357 | 45 | **900729 Tiburon Replacement** |  | 254d | 2007-01-02 | 2007-12-21 |  | 16d |  |  |  | 1360h |
| 358 | 45.1 | Requirement document | milestone | 0d | 2007-01-23 | 2007-01-23 |  | 255d |  | start no earlier than 2007-01-23 |  |  |
| 359 | 45.2 | Completed contract | milestone | 0d | 2007-02-14 | 2007-02-14 |  | 239d |  | start no earlier than 2007-02-14 |  |  |
| 360 | 45.3 | PDR | milestone | 0d | 2007-03-14 | 2007-03-14 |  | 195d | 0d | start no earlier than 2007-03-14 |  |  |
| 361 | 45.4 | Supp Eng leading to CDR (Mike R) |  | 75d | 2007-01-02 | 2007-04-16 |  | 195d |  |  | Supp Eng [30.7%] | 184h |
| 362 | 45.5 | ME leading to CDR (Brett) |  | 75d | 2007-01-02 | 2007-04-16 |  | 195d |  |  | ME [26.7%] | 160h |
| 363 | 45.6 | ME leading to CDR (Mark B) |  | 75d | 2007-01-02 | 2007-04-16 |  | 195d |  |  | ME [26.7%] | 160h |
| 364 | 45.7 | EE leading to CDR (Ed) |  | 24d | 2007-03-14 | 2007-04-16 | 360 | 195d |  |  | EE [20.8%] | 40h |
| 365 | 45.8 | ME Tech to CDR (Larry) |  | 70d | 2007-01-02 | 2007-04-09 |  | 200d |  | start no earlier than 2007-01-02 | ME Tech [14.3%] | 80h |
| 366 | 45.9 | CDR | milestone | 0d | 2007-04-16 | 2007-04-16 |  | 71d | 0d | start no earlier than 2007-04-16 |  |  |
| 367 | 45.10 | Supp Eng (Rich S) |  | 125d | 2007-04-16 | 2007-10-05 | 366 | 71d | 0d | start no earlier than 2007-04-02 | Supp Eng [24%] | 240h |
| 368 | 45.11 | SE (Bob H) |  | 125d | 2007-04-16 | 2007-10-05 | 367SS | 71d |  |  | SE [12%] | 120h |
| 369 | 45.12 | ME leading to FAT (Brett) |  | 125d | 2007-04-16 | 2007-10-05 | 367SS | 71d |  |  | ME [8%] | 80h |
| 370 | 45.13 | ME leading to FAT (Mark B) |  | 125d | 2007-04-16 | 2007-10-05 | 367SS | 71d |  |  | ME [8%] | 80h |
| 371 | 45.14 | FAT | milestone | 0d | 2007-10-03 | 2007-10-03 |  | 74d |  | start no earlier than 2007-10-03 |  |  |
| 372 | 45.15 | ME Tech to FAT (Larry) |  | 30d | 2007-11-12 | 2007-12-21 |  | 16d |  | start no earlier than 2007-11-12 | ME Tech [16.7%] | 40h |
| 373 | 45.16 | Machinist (VB and frame) |  | 60d | 2007-07-02 | 2007-09-21 |  | 81d |  | start no earlier than 2007-07-02 | Machinist [36.7%] | 176h |

| ID | WBS | Task | Type | Duration | Start | Finish | Predecessors | Total slack | Free slack | Constraint | Resources | Work |
| --- | --- | --- | --- | --- | --- | --- | --- | --- | --- | --- | --- | --- |
| 374 | 46 | **900731 Data Handling for Eye in the Sea** |  | 270d | 2007-01-02 | 2008-01-14 |  | 0d |  |  |  | 1600h |
| 375 | 46.1 | **Documentation** |  | 110d | 2007-01-02 | 2007-06-04 |  | 160d |  |  |  | 160h |
| 376 | 46.1.1 | SE |  | 110d | 2007-01-02 | 2007-06-04 |  | 160d |  |  | SE [18.2%] | 160h |
| 377 | 46.2 | **VARS integration** |  | 130d | 2007-01-02 | 2007-07-02 |  | 140d |  |  |  | 240h |
| 378 | 46.2.1 | Supp Eng |  | 130d | 2007-01-02 | 2007-07-02 |  | 140d |  |  | Supp Eng [23.1%] | 240h |
| 379 | 46.3 | **Integrate, test deploy AVED** |  | 150d | 2007-01-02 | 2007-07-30 |  | 0d |  |  |  | 880h |
| 380 | 46.3.1 | SE |  | 150d | 2007-01-02 | 2007-07-30 |  | 0d |  |  | SE [53.3%] | 640h |
| 381 | 46.3.2 | Supp eng |  | 150d | 2007-01-02 | 2007-07-30 |  | 0d |  |  | Supp Eng [13.3%] | 160h |
| 382 | 46.3.3 | SE Tech |  | 150d | 2007-01-02 | 2007-07-30 |  | 0d |  |  | SE Tech [6.7%] | 80h |
| 383 | 46.4 | Prototye demonstration and review | milestone | 0d | 2007-04-11 | 2007-04-11 |  | 199d |  | start no earlier than 2007-04-11 |  |  |
| 384 | 46.5 | Ship system to Florida for testing | milestone | 0d | 2007-08-15 | 2007-08-15 |  | 109d |  | start no earlier than 2007-08-15 |  |  |
| 385 | 46.6 | Test system on MARS | milestone | 0d | 2007-11-14 | 2007-11-14 |  | 44d |  | start no earlier than 2007-11-14 |  |  |
| 386 | 46.7 | **AVED dissemination plan complete** |  | 120d | 2007-07-31 | 2008-01-14 | 379 | 0d |  |  |  | 320h |
| 387 | 46.7.1 | SE |  | 120d | 2007-07-31 | 2008-01-14 |  | 0d |  |  | SE [33.3%] | 320h |
| 388 | 47 | **900732 MARS Wet Node Simulator** |  | 170d | 2007-01-02 | 2007-08-27 |  | 100d |  |  |  | 440h |
| 389 | 47.1 | **Requirements** |  | 26.67d | 2007-01-02 | 2007-02-07 |  | 100d | 0d |  |  | 48h |
| 390 | 47.1.1 | EE |  | 26.67d | 2007-01-02 | 2007-02-07 |  | 100d |  |  | EE [15%] | 32h |
| 391 | 47.1.2 | ME |  | 20d | 2007-01-02 | 2007-01-29 |  | 106.67d |  |  | ME [10%] | 16h |
| 392 | 47.2 | **PDR** |  | 25d | 2007-02-07 | 2007-03-14 | 389 | 100d | 0d |  |  | 64h |
| 393 | 47.2.1 | EE |  | 25d | 2007-02-07 | 2007-03-14 |  | 100d |  |  | EE [24%] | 48h |
| 394 | 47.2.2 | ME |  | 9.09d | 2007-02-07 | 2007-02-20 |  | 115.91d |  |  | ME [22%] | 16h |
| 395 | 47.3 | **CDR** |  | 33.33d | 2007-03-14 | 2007-04-30 | 392 | 100d | 0d |  |  | 96h |
| 396 | 47.3.1 | EE |  | 33.33d | 2007-03-14 | 2007-04-30 |  | 100d |  |  | EE [24%] | 64h |
| 397 | 47.3.2 | ME |  | 20d | 2007-03-14 | 2007-04-11 |  | 113.33d |  |  | ME [20%] | 32h |

| ID | WBS | Task | Duration | Start | Finish | Predecessors | Total slack | Free slack | Resources | Work |
| --- | --- | --- | --- | --- | --- | --- | --- | --- | --- | --- |
| 398 | 47.4 | **Build/Acceptance tests** | 65d | 2007-05-01 | 2007-07-30 | 395 | 100d | 0d |  | 216h |
| 399 | 47.4.1 | EE | 12.5d | 2007-05-01 | 2007-05-17 |  | 152.5d |  | EE [40%] | 40h |
| 400 | 47.4.2 | ME | 32.5d | 2007-05-01 | 2007-06-14 |  | 132.5d |  | ME [6.2%] | 16h |
| 401 | 47.4.3 | EE Tech | 65d | 2007-05-01 | 2007-07-30 |  | 100d |  | EE Tech [15.4%] | 80h |
| 402 | 47.4.4 | ME Tech | 65d | 2007-05-01 | 2007-07-30 |  | 100d |  | ME Tech [7.7%] | 40h |
| 403 | 47.4.5 | Machinist | 65d | 2007-05-01 | 2007-07-30 |  | 100d |  | Machinist [7.7%] | 40h |
| 404 | 47.5 | **Documentation** | 20d | 2007-07-31 | 2007-08-27 | 398 | 100d |  |  | 16h |
| 405 | 47.5.1 | EE | 20d | 2007-07-31 | 2007-08-27 |  | 100d |  | EE [10%] | 16h |
| 406 | 48 | **900733 Extension Cables for Ocean Observatories** | 260d | 2007-01-02 | 2007-12-31 |  | 10d |  |  | 1256h |
| 407 | 48.1 | EE | 260d | 2007-01-02 | 2007-12-31 |  | 10d |  | EE [11.2%] | 232h |
| 408 | 48.2 | ME | 260d | 2007-01-02 | 2007-12-31 |  | 10d |  | ME [31.2%] | 648h |
| 409 | 48.3 | EE Tech | 260d | 2007-01-02 | 2007-12-31 |  | 10d |  | EE Tech [3.8%] | 80h |
| 410 | 48.4 | ME Tech | 260d | 2007-01-02 | 2007-12-31 |  | 10d |  | ME Tech [8.1%] | 168h |
| 411 | 48.5 | Machinist | 260d | 2007-01-02 | 2007-12-31 |  | 10d |  | Machinist [6.2%] | 128h |
| 412 | 49 | **900737 Benthic Rover** | 240d | 2007-01-02 | 2007-12-03 |  | 30d |  |  | 3912h |
| 413 | 49.1 | **Scanner integration** | 65d | 2007-01-02 | 2007-04-02 |  | 30d | 0d |  | 1480h |
| 414 | 49.1.1 | EE | 65d | 2007-01-02 | 2007-04-02 |  | 30d |  | EE [61.5%] | 320h |
| 415 | 49.1.2 | SE | 65d | 2007-01-02 | 2007-04-02 |  | 30d |  | SE [69.2%] | 360h |
| 416 | 49.1.3 | ME | 65d | 2007-01-02 | 2007-04-02 |  | 30d |  | ME [46.2%] | 240h |
| 417 | 49.1.4 | EE Tech | 65d | 2007-01-02 | 2007-04-02 |  | 30d |  | EE Tech [30.8%] | 160h |
| 418 | 49.1.5 | ME Tech | 65d | 2007-01-02 | 2007-04-02 |  | 30d |  | ME Tech [30.8%] | 160h |
| 419 | 49.1.6 | Machinist | 65d | 2007-01-02 | 2007-04-02 |  | 30d |  | Machinist [46.2%] | 240h |
| 420 | 49.2 | **Tethered deployment on MARS** | 115d | 2007-04-03 | 2007-09-10 | 413 | 30d | 0d |  | 1320h |
| 421 | 49.2.1 | EE | 115d | 2007-04-03 | 2007-09-10 |  | 30d |  | EE [34.8%] | 320h |
| 422 | 49.2.2 | SE | 115d | 2007-04-03 | 2007-09-10 |  | 30d |  | SE [69.6%] | 640h |
| 423 | 49.2.3 | ME | 115d | 2007-04-03 | 2007-09-10 |  | 30d |  | ME [21.7%] | 200h |
| 424 | 49.2.4 | EE Tech | 115d | 2007-04-03 | 2007-09-10 |  | 30d |  | EE Tech [8.7%] | 80h |
| 425 | 49.2.5 | ME Tech | 115d | 2007-04-03 | 2007-09-10 |  | 30d |  | ME Tech [8.7%] | 80h |

| ID | WBS | Task | Duration | Start | Finish | Predecessors | Total slack | Free slack | Resources | Work |
| --- | --- | --- | --- | --- | --- | --- | --- | --- | --- | --- |
| 426 | 49.3 | **Second tethered deployment** | 60d | 2007-09-11 | 2007-12-03 | 420 | 30d |  |  | 760h |
| 427 | 49.3.1 | EE | 60d | 2007-09-11 | 2007-12-03 |  | 30d |  | EE [33.3%] | 160h |
| 428 | 49.3.2 | SE | 60d | 2007-09-11 | 2007-12-03 |  | 30d |  | SE [58.3%] | 280h |
| 429 | 49.3.3 | ME | 60d | 2007-09-11 | 2007-12-03 |  | 30d |  | ME [33.3%] | 160h |
| 430 | 49.3.4 | EE Tech | 60d | 2007-09-11 | 2007-12-03 |  | 30d |  | EE Tech [16.7%] | 80h |
| 431 | 49.3.5 | ME Tech | 60d | 2007-09-11 | 2007-12-03 |  | 30d |  | ME Tech [16.7%] | 80h |
| 432 | 49.4 | **Publications** | 55d | 2007-09-11 | 2007-11-26 | 420 | 35d |  |  | 352h |
| 433 | 49.4.1 | EE | 55d | 2007-09-11 | 2007-11-26 |  | 35d |  | EE [36.4%] | 160h |
| 434 | 49.4.2 | SE | 55d | 2007-09-11 | 2007-11-26 |  | 35d |  | SE [18.2%] | 80h |
| 435 | 49.4.3 | ME | 55d | 2007-09-11 | 2007-11-26 |  | 35d |  | ME [18.2%] | 80h |
| 436 | 49.4.4 | EE Tech | 55d | 2007-09-11 | 2007-11-26 |  | 35d |  | EE Tech [3.6%] | 16h |
| 437 | 49.4.5 | ME Tech | 55d | 2007-09-11 | 2007-11-26 |  | 35d |  | ME Tech [3.6%] | 16h |
| 438 | 50 | **900739 LRAUV** | 180d | 2007-01-02 | 2007-09-10 |  | 90d |  |  | 1400h |
| 439 | 50.1 | **Reference design** | 45d | 2007-01-02 | 2007-03-05 |  | 20d | 0d |  | 320h |
| 440 | 50.1.1 | EE | 45d | 2007-01-02 | 2007-03-05 |  | 20d |  | EE [22.2%] | 80h |
| 441 | 50.1.2 | SE | 45d | 2007-01-02 | 2007-03-05 |  | 20d |  | SE [33.3%] | 120h |
| 442 | 50.1.3 | ME | 45d | 2007-01-02 | 2007-03-05 |  | 20d |  | ME [33.3%] | 120h |
| 443 | 50.2 | **Reference design validation** | 90d | 2007-03-06 | 2007-07-09 | 439 | 90d | 0d |  | 920h |
| 444 | 50.2.1 | EE | 65d | 2007-03-06 | 2007-06-04 |  | 115d |  | EE [15.4%] | 80h |
| 445 | 50.2.2 | SE | 65d | 2007-03-06 | 2007-06-04 |  | 115d |  | SE [23.1%] | 120h |
| 446 | 50.2.3 | ME | 65d | 2007-03-06 | 2007-06-04 |  | 115d |  | ME [15.4%] | 80h |
| 447 | 50.2.4 | EE Tech | 65d | 2007-03-06 | 2007-06-04 |  | 115d |  | EE Tech [23.1%] | 120h |
| 448 | 50.2.5 | ME Tech | 65d | 2007-03-06 | 2007-06-04 |  | 115d |  | ME Tech [7.7%] | 40h |
| 449 | 50.2.6 | Machinist | 90d | 2007-03-06 | 2007-07-09 |  | 90d |  | Machinist [66.7%] | 480h |

| ID | WBS | Task | Duration | Start | Finish | Predecessors | Total slack | Resources | Work |
| --- | --- | --- | --- | --- | --- | --- | --- | --- | --- |
| 450 | 50.3 | **Project plan** | 45d | 2007-07-10 | 2007-09-10 | 443 | 90d |  | 160h |
| 451 | 50.3.1 | EE | 45d | 2007-07-10 | 2007-09-10 |  | 90d | EE [22.2%] | 80h |
| 452 | 50.3.2 | SE | 45d | 2007-07-10 | 2007-09-10 |  | 90d | SE [11.1%] | 40h |
| 453 | 50.3.3 | ME | 45d | 2007-07-10 | 2007-09-10 |  | 90d | ME [11.1%] | 40h |
